# طراحی و ساخت درایو کنترل دور موتور

Schedule from MS Project, 2019-07-06 to 2022-03-19, status date 2021-07-22, A marks actual dates.

## Calendars

- Standard: Mon-Sun 08:00-12:00, 13:00-17:00.

## Schedule

| ID | WBS | Task | Type | Duration | Start | Finish | Predecessors | Complete | Remaining | Baseline start | Baseline finish | Baseline duration | Total slack | Free slack | شروع | پایان |
| --- | --- | --- | --- | --- | --- | --- | --- | --- | --- | --- | --- | --- | --- | --- | --- | --- |
| 1 | 1 | شروع | milestone | 0d | 2019-07-06 A | 2019-07-06 A |  | 100% |  | 2019-07-06 | 2019-07-06 | 0d |  |  | 1398/04/15 | 1398/04/15 |
| 2 | 2 | **مطالعات** |  | 235d | 2019-07-06 A | 2020-02-25 A |  | 100% |  | 2019-07-06 | 2020-02-25 | 235d |  |  | 1398/04/15 | 1398/12/06 |
| 3 | 2.1 | ابلاغ قرارداد | milestone | 0d | 2019-07-06 A | 2019-07-06 A | 1 | 100% |  | 2019-07-06 | 2019-07-06 | 0d |  |  | 1398/04/15 | 1398/04/15 |
| 4 | 2.2 | تهیه برنامه زمانبندی |  | 121d | 2019-07-06 A | 2019-11-03 A | 3 | 100% |  | 2019-07-06 | 2019-11-03 | 121d |  |  | 1398/04/15 | 1398/08/12 |
| 5 | 2.3 | تایید برنامه زمانبندی |  | 3d | 2019-11-04 A | 2019-11-06 A | 4 | 100% |  | 2019-11-04 | 2019-11-06 | 3d |  |  | 1398/08/13 | 1398/08/15 |
| 6 | 2.4 | مطالعه ساختار قدرت |  | 45d | 2019-11-07 A | 2019-12-21 A | 5 | 100% |  | 2019-11-07 | 2019-12-21 | 45d |  |  | 1398/08/16 | 1398/09/30 |
| 7 | 2.5 | انتخاب ساختار قدرت |  | 2d | 2019-12-22 A | 2019-12-23 A | 6 | 100% |  | 2019-12-22 | 2019-12-23 | 2d |  |  | 1398/10/01 | 1398/10/02 |
| 8 | 2.6 | مطالعه ساختار کنترل |  | 38d | 2019-12-24 A | 2020-01-30 A | 7 | 100% |  | 2019-12-24 | 2020-01-30 | 38d |  |  | 1398/10/03 | 1398/11/10 |
| 9 | 2.7 | انتخاب ساختار کنترل |  | 14d | 2020-01-31 A | 2020-02-13 A | 8 | 100% |  | 2020-01-31 | 2020-02-13 | 14d |  |  | 1398/11/11 | 1398/11/24 |
| 10 | 2.8 | مطالعه و انتخاب سیستم خنک سازی |  | 12d | 2020-02-14 A | 2020-02-25 A | 9 | 100% |  | 2020-02-14 | 2020-02-25 | 12d |  |  | 1398/11/25 | 1398/12/06 |
| 11 | 3 | **طراحی و محاسبات** |  | 119d | 2019-12-24 A | 2020-04-20 A |  | 100% |  | 2019-12-24 | 2020-04-20 | 119d |  |  | 1398/10/03 | 1399/02/01 |
| 12 | 3.1 | طراحی اینورتر |  | 52d | 2019-12-24 A | 2020-02-13 A | 7, 6 | 100% |  | 2019-12-24 | 2020-02-13 | 52d |  |  | 1398/10/03 | 1398/11/24 |
| 13 | 3.2 | طراحی رکتیفایر |  | 38d | 2019-12-24 A | 2020-01-30 A | 7 | 100% |  | 2019-12-24 | 2020-01-30 | 38d |  |  | 1398/10/03 | 1398/11/10 |
| 14 | 3.3 | طراحی ترانسفورماتور |  | 38d | 2019-12-24 A | 2020-01-30 A | 7 | 100% |  | 2019-12-24 | 2020-01-30 | 38d |  |  | 1398/10/03 | 1398/11/10 |
| 15 | 3.4 | طراحی کنترل |  | 53d | 2020-02-14 A | 2020-04-06 A | 8, 9 | 100% |  | 2020-02-14 | 2020-04-06 | 53d |  |  | 1398/11/25 | 1399/01/18 |
| 16 | 3.5 | طراحی حفاظت |  | 14d | 2020-04-07 A | 2020-04-20 A | 15 | 100% |  | 2020-04-07 | 2020-04-20 | 14d |  |  | 1399/01/19 | 1399/02/01 |
| 17 | 3.6 | طراحی خنک سازی |  | 8d | 2020-02-26 A | 2020-03-04 A | 12, 13, 10 | 100% |  | 2020-02-26 | 2020-03-04 | 8d |  |  | 1398/12/07 | 1398/12/14 |
| 18 | 4 | **ماژول 120 کیلو وات** |  | 129d | 2020-02-14 A | 2020-06-21 A |  | 100% |  | 2020-02-14 | 2020-06-21 | 129d |  |  | 1398/11/25 | 1399/04/01 |
| 19 | 4.1 | تامین قطعات نمونه آزمایشگاهی |  | 4d | 2020-02-14 A | 2020-02-17 A | 12, 13, 14 | 100% |  | 2020-02-14 | 2020-02-17 | 4d |  |  | 1398/11/25 | 1398/11/28 |
| 20 | 4.2 | ساخت نمونه آزمایشگاهی |  | 15d | 2020-02-18 A | 2020-03-03 A | 19 | 100% |  | 2020-02-18 | 2020-03-03 | 15d |  |  | 1398/11/29 | 1398/12/13 |
| 21 | 4.3 | تست نمونه آزمایشگاهی |  | 110d | 2020-03-04 A | 2020-06-21 A | 20 | 100% |  | 2020-03-04 | 2020-06-21 | 110d |  |  | 1398/12/14 | 1399/04/01 |
| 22 | 5 | **ماژول 2.5 مگاوات اول** |  | 503d | 2020-06-22 A | 2021-11-06 |  | 65% | 177.31d | 2020-06-22 | 2022-01-07 | 565d | 0d |  | 1399/04/02 | 1400/08/15 |
| 23 | 5.1 | تامین قطعات 7.5 مگاوات |  | 400d | 2020-06-22 A | 2021-07-26 | 21 | 92% | 32d | 2020-06-22 | 2021-07-26 | 400d | 60d | 0d | 1399/04/02 | 1400/05/04 |
| 24 | 5.2 | تهیه و طراحی بردها |  | 65d | 2021-05-24 A | 2021-07-27 | 23FS-64d | 92% | 5d | 2021-05-24 | 2021-07-27 | 65d | 0d |  | 1400/03/03 | 1400/05/05 |

| ID | WBS | Task | Type | Duration | Start | Finish | Predecessors | Baseline start | Baseline finish | Baseline duration | Total slack | Free slack | شروع | پایان |
| --- | --- | --- | --- | --- | --- | --- | --- | --- | --- | --- | --- | --- | --- | --- |
| 25 | 5.3 | **ساخت و مونتاژ بخش قدرت** |  | 52d | 2021-07-28 | 2021-09-17 |  | 2021-07-28 | 2021-10-29 | 94d | 0d |  | 1400/05/06 | 1400/06/26 |
| 26 | 5.3.1 | مونتاژ کلی ماژول ها در تابلوی اینورتر |  | 13d | 2021-07-28 | 2021-08-09 | 24 | 2021-07-28 | 2021-08-08 | 12d | 0d |  | 1400/05/06 | 1400/05/18 |
| 27 | 5.3.2 | انجام کابل کشی،شین کشی و سیم کشی های اینورتر |  | 13d | 2021-08-10 | 2021-08-22 | 26 | 2021-08-09 | 2021-08-20 | 12d | 0d |  | 1400/05/19 | 1400/05/31 |
| 28 | 5.3.3 | مونتاژ جداگانه ماژول های رکتیفایر |  | 13d | 2021-08-10 | 2021-08-22 | 27SS | 2021-08-09 | 2021-08-20 | 12d | 0d |  | 1400/05/19 | 1400/05/31 |
| 29 | 5.3.4 | مونتاژ کلی ماژول ها در تابلوی رکتیفایر |  | 13d | 2021-08-23 | 2021-09-04 | 28 | 2021-08-21 | 2021-09-24 | 35d | 0d |  | 1400/06/01 | 1400/06/13 |
| 30 | 5.3.5 | انجام کابل کشی،شین کشی و سیم کشی های رکتیفایر |  | 13d | 2021-09-05 | 2021-09-17 | 29 | 2021-09-25 | 2021-10-29 | 35d | 0d |  | 1400/06/14 | 1400/06/26 |
| 31 | 5.3.6 | مونتاژ بخش های مختلف ترانسفورماتور |  | 13d | 2021-07-28 | 2021-08-09 | 24 | 2021-07-28 | 2021-08-31 | 35d | 26d | 0d | 1400/05/06 | 1400/05/18 |
| 32 | 5.3.7 | قرار دادن بخش های مختلف ترانسفورماتور در مخزن یا تابلو |  | 13d | 2021-08-10 | 2021-08-22 | 31 | 2021-09-01 | 2021-10-05 | 35d | 26d |  | 1400/05/19 | 1400/05/31 |
| 33 | 5.4 | **ساخت و مونتاژ بخش کنترل** |  | 30d | 2021-07-28 | 2021-08-26 |  | 2021-07-28 | 2021-08-26 | 30d | 22d |  | 1400/05/06 | 1400/06/04 |
| 34 | 5.4.1 | مونتاژبردهای کنترلی |  | 20d | 2021-07-28 | 2021-08-16 | 24 | 2021-07-28 | 2021-08-16 | 20d | 22d | 0d | 1400/05/06 | 1400/05/25 |
| 35 | 5.4.2 | قراردادن بردهای کنترلی در تابلو |  | 10d | 2021-08-17 | 2021-08-26 | 34 | 2021-08-17 | 2021-08-26 | 10d | 22d |  | 1400/05/26 | 1400/06/04 |
| 36 | 5.5 | **تست کارگاهی** |  | 50d | 2021-09-18 | 2021-11-06 |  | 2021-08-27 | 2022-01-07 | 134d | 0d |  | 1400/06/27 | 1400/08/15 |
| 37 | 5.5.1 | فراهم کردن بستر تست مناسب |  | 25d | 2021-09-18 | 2021-10-12 | 35, 27, 30, 32 | 2021-11-29 | 2021-12-18 | 20d | 0d |  | 1400/06/27 | 1400/07/20 |
| 38 | 5.5.2 | تست کل سیستم در ولتاژ نامی جریان پایین |  | 25d | 2021-10-13 | 2021-11-06 | 37, 35, 27, 30, 32 | 2021-12-19 | 2022-01-07 | 20d | 0d |  | 1400/07/21 | 1400/08/15 |
| 39 | 5.5.3 | تست کل سیستم در جریان نامی ولتاژ پایین |  | 25d | 2021-10-13 | 2021-11-06 | 37, 35, 27, 30, 32 | 2021-12-19 | 2022-01-07 | 20d | 0d |  | 1400/07/21 | 1400/08/15 |
| 40 | 5.6 | پایان ساخت و مونتاژ ماژول اول 2.5 مگاوات | milestone | 0d | 2021-11-06 | 2021-11-06 | 38, 39 | 2022-01-07 | 2022-01-07 | 0d | 0d |  | 1400/08/15 | 1400/08/15 |
| 41 | 6 | **دو ماژول 2.5 مگاوات دوم** |  | 133d | 2021-11-07 | 2022-03-19 |  | 2022-01-08 | 2022-06-27 | 171d | 0d |  | 1400/08/16 | 1400/12/28 |
| 42 | 6.1 | مقدمات شروع ساخت |  | 13d | 2021-11-07 | 2021-11-19 | 40 | 2022-01-08 | 2022-01-14 | 7d | 0d |  | 1400/08/16 | 1400/08/28 |
| 43 | 6.2 | **ساخت و مونتاژ بخش قدرت** |  | 100d | 2021-11-20 | 2022-02-27 |  | 2022-01-15 | 2022-04-18 | 94d | 0d |  | 1400/08/29 | 1400/12/08 |
| 44 | 6.2.1 | مونتاژ کلی ماژول ها در تابلوی اینورتر |  | 25d | 2021-11-20 | 2021-12-14 | 42 | 2022-01-15 | 2022-01-26 | 12d | 0d |  | 1400/08/29 | 1400/09/23 |
| 45 | 6.2.2 | انجام کابل کشی،شین کشی و سیم کشی های اینورتر |  | 25d | 2021-12-15 | 2022-01-08 | 44 | 2022-01-27 | 2022-02-07 | 12d | 0d |  | 1400/09/24 | 1400/10/18 |
| 46 | 6.2.3 | مونتاژ جداگانه ماژول های رکتیفایر |  | 25d | 2021-12-15 | 2022-01-08 | 45SS | 2022-01-27 | 2022-02-07 | 12d | 0d |  | 1400/09/24 | 1400/10/18 |
| 47 | 6.2.4 | مونتاژ کلی ماژول ها در تابلوی رکتیفایر |  | 25d | 2022-01-09 | 2022-02-02 | 46 | 2022-02-08 | 2022-03-14 | 35d | 0d |  | 1400/10/19 | 1400/11/13 |
| 48 | 6.2.5 | انجام کابل کشی،شین کشی و سیم کشی های رکتیفایر |  | 25d | 2022-02-03 | 2022-02-27 | 47 | 2022-03-15 | 2022-04-18 | 35d | 0d |  | 1400/11/14 | 1400/12/08 |
| 49 | 6.2.6 | مونتاژ بخش های مختلف ترانسفورماتور |  | 25d | 2021-11-20 | 2021-12-14 | 42 | 2022-01-15 | 2022-02-18 | 35d | 50d | 0d | 1400/08/29 | 1400/09/23 |
| 50 | 6.2.7 | قرار دادن بخش های مختلف ترانسفورماتور در مخزن یا تابلو |  | 25d | 2021-12-15 | 2022-01-08 | 49 | 2022-02-19 | 2022-03-25 | 35d | 50d |  | 1400/09/24 | 1400/10/18 |

| ID | WBS | Task | Type | Duration | Start | Finish | Predecessors | Baseline start | Baseline finish | Baseline duration | Total slack | Free slack | شروع | پایان |
| --- | --- | --- | --- | --- | --- | --- | --- | --- | --- | --- | --- | --- | --- | --- |
| 51 | 6.3 | **ساخت و مونتاژ بخش کنترل** |  | 50d | 2021-11-20 | 2022-01-08 |  | 2022-01-15 | 2022-02-13 | 30d | 50d |  | 1400/08/29 | 1400/10/18 |
| 52 | 6.3.1 | مونتاژبردهای کنترلی |  | 35d | 2021-11-20 | 2021-12-24 | 42 | 2022-01-15 | 2022-02-03 | 20d | 50d | 0d | 1400/08/29 | 1400/10/03 |
| 53 | 6.3.2 | قراردادن بردهای کنترلی در تابلو |  | 15d | 2021-12-25 | 2022-01-08 | 52 | 2022-02-04 | 2022-02-13 | 10d | 50d |  | 1400/10/04 | 1400/10/18 |
| 54 | 6.4 | **تست کارگاهی** |  | 20d | 2022-02-28 | 2022-03-19 |  | 2022-02-14 | 2022-06-27 | 134d | 0d |  | 1400/12/09 | 1400/12/28 |
| 55 | 6.4.1 | فراهم کردن بستر تست مناسب |  | 10d | 2022-02-28 | 2022-03-09 | 45, 48, 50, 53 | 2022-05-19 | 2022-06-07 | 20d | 0d |  | 1400/12/09 | 1400/12/18 |
| 56 | 6.4.2 | تست کل سیستم در ولتاژ نامی جریان پایین |  | 10d | 2022-03-10 | 2022-03-19 | 55 | 2022-06-08 | 2022-06-27 | 20d | 0d |  | 1400/12/19 | 1400/12/28 |
| 57 | 6.4.3 | تست کل سیستم در جریان نامی ولتاژ پایین |  | 10d | 2022-03-10 | 2022-03-19 | 55 | 2022-06-08 | 2022-06-27 | 20d | 0d |  | 1400/12/19 | 1400/12/28 |
| 58 | 6.5 | پایان دو ماژول 2.5 مگاوات | milestone | 0d | 2022-03-19 | 2022-03-19 | 56, 57 | 2022-06-27 | 2022-06-27 | 0d | 0d |  | 1400/12/28 | 1400/12/28 |
| 59 | 7 | پایان | milestone | 0d | 2022-03-19 | 2022-03-19 | 40, 58 | 2022-06-27 | 2022-06-27 | 0d | 0d |  | 1400/12/28 | 1400/12/28 |
